# FPAP

Schedule from MS Project, 2003-04-01 to 2009-09-29, costs in $, A marks actual dates.

## Calendars

- Standard: Mon-Fri 08:00-12:00, 13:00-17:00; Sat-Sun off.

## Resources

| Resource | Rate |
| --- | --- |
| overtime | 1716 |
| PPPL Travel | 1729 |
| stockroom | 1729 |
| M&S no escalation | 1281 |
| PPPL M&S | 1274 |
| $k myatt at 125 hr | 1274 |
| $k ritus at 124 hr | 1274 |
| contingency M&S | 1274 |
| PPPL M&S exempt | 1000 |
| Allocations | 1665 |
| no G&A cost | 1000 |
| cost adjustment |  |
| full G&A cost (labor cont) | 1695 |
| PPPL Project Clerical | 39.85 |
| Len Myatt | 161.25 |
| PPPL Analysis engineer | 154.5 |
| PPPL Designer | 116.7 |
| PPPL Designer | 101.4 |
| PPPL Comuter Engineer | 144.91 |
| PPPL Computer Senior tech b/w | 93.69 |
| PPPL Computer Senior Tech | 89.3 |
| PPPL Electrical engineer | 150.7 |
| PPPL Electrical Senior Tech | 110.57 |
| PPPL Electrical Technician | 75.7 |
| PPPL FO&M Engineer | 160.42 |
| PPPL FO&M Senior Tech | 105.02 |
| PPPL FO&M Technician | 74.52 |
| PPPL P&CO am | 132.2 |
| PPPL P&CO em | 165.25 |
| ORNL Travel | 1000 |
| ORNL M&S | 1000 |
| ORNL cost | 1000 |
| ORNL Admin | 137.64 |
| ORNL Engineer | 128.69 |
| ORNL Scientist | 171 |
| PPPL Scientist pdg2 | 148.2 |
| PPPL Scientist pdg3 | 214.7 |
| HP Techs | 96.1 |
| Metrology equipt |  |
| contingency-ornl | 1000 |
| contingency-pppl-labor | 1000 |
| contingency-pppl-m&s | 1000 |

## Schedule

| ID | WBS | Task | Duration | Start | Finish | Predecessors | Complete | Remaining | Total slack | Free slack | Constraint | Resources | Work | Actual work | Cost | Actual cost | Text2 | Text3 | Text5 | Text6 | Text7 | Text10 |
| --- | --- | --- | --- | --- | --- | --- | --- | --- | --- | --- | --- | --- | --- | --- | --- | --- | --- | --- | --- | --- | --- | --- |
| 2 | 1 | Metrology Engr Super FY07 | 261.87d | 2006-10-02 A | 2007-09-28 |  | 47% | 139.86d | 0d |  | must finish on 2007-09-28 | PPPL FO&M Engineer [43%] | 863h | 423h | 138,442.46 | 67,857.66 | 18 | 181 | 9450 | RBSE | 1802 | R1802-001 |
| 3 | 2 | Metrology Engr Super FY08 | 262.87d | 2007-10-01 | 2008-10-01 |  |  |  | 258.13d |  | start no earlier than 2007-10-01 | PPPL FO&M Engineer [43%] | 863h |  | 138,442.46 |  | 18 | 181 | 9450 | RBSE | 1802 | R1802-003 |
| 4 | 3 | PPPL EM LOE FY07 | 259d | 2006-10-02 A | 2007-09-28 |  | 47% | 136.99d | 0d |  | must finish on 2007-09-28 | PPPL FO&M Engineer [87%] | 1726h | 846h | 276,884.92 | 135,715.32 | 18 | 181 | 9450 | RBSE | 1802 | R1802-005 |
| 5 | 4 | PPPL EM LOE FY08 | 262.87d | 2007-10-01 | 2008-10-01 |  |  |  | 258.13d |  | start no earlier than 2007-10-01 | PPPL FO&M Engineer [86%] | 1726h |  | 276,884.92 |  | 18 | 181 | 9450 | RBSE | 1802 | R1802-007 |
| 6 | 5 | Title III field period assy FY07 ORNL | 261.67d | 2006-10-02 A | 2007-09-28 |  | 47% | 139.66d | 0d |  | must finish on 2007-09-28 | ORNL Engineer [56%] | 1123h | 550h | 144,518.87 | 70,779.5 | 18 | 181 | 9450 | RBSE | 1802 | R1802-009 |
| 7 | 6 | Title III field period assy FY08 ORNL | 262.89d | 2007-10-01 | 2008-10-01 |  |  |  | 258.11d |  | start no earlier than 2007-10-01 | ORNL Engineer [28%] | 562h |  | 72,323.78 |  | 18 | 181 | 9450 | RBSE | 1802 | R1802-011 |
| 8 | 7 | HP Coverage in the TFTR TC LOE FY07 | 260.04d | 2006-10-02 A | 2007-09-28 |  | 47% | 138.03d | 0d |  | must finish on 2007-09-28 | PPPL FO&M Engineer [65%] | 1295h | 634h | 207,743.9 | 101,706.28 | 18 | 181 | 9450 | RBSE | 1802 | R1802-013 |
| 9 | 8 | HP Coverage in the TFTR TC LOE FY08 | 261.04d | 2007-10-01 | 2008-09-30 |  |  |  | 259.97d |  | start no earlier than 2007-10-01 | PPPL FO&M Engineer [65%] | 1295h |  | 207,743.9 |  | 18 | 181 | 9450 | RBSE | 1802 | R1802-015 |
| 10 | 9 | Sequence plan | 1d | 2007-04-30 | 2007-04-30 |  |  |  | 600d | 0d | start no earlier than 2007-04-30 |  |  |  |  |  | 18 | 181 | 9450 | RBSE | 1802 | R1802-203 |
| 11 | 10 | Metrology plan | 1d | 2007-04-30 | 2007-04-30 |  |  |  | 600d | 0d | start no earlier than 2007-04-30 |  |  |  |  |  | 18 | 181 | 9450 | RBSE | 1802 | R1802-205 |
| 12 | 11 | Procedures written & approved | 14d | 2007-05-01 | 2007-05-18 | 10, 11 |  |  | 600d | 0d |  |  |  |  |  |  | 18 | 181 | 9450 | RBSE | 1802 | R1802-207 |
| 13 | 12 | JHA completed | 6d | 2007-05-21 | 2007-05-28 | 12 |  |  | 600d | 0d |  |  |  |  |  |  | 18 | 181 | 9450 | RBSE | 1802 | R1802-209 |
| 14 | 13 | Training needs identified & released | 6d | 2007-05-29 | 2007-06-05 | 13 |  |  | 600d | 0d |  |  |  |  |  |  | 18 | 181 | 9450 | RBSE | 1802 | R1802-211 |
| 15 | 14 | ACC review completed | 2d | 2007-06-06 | 2007-06-07 | 14 |  |  | 600d | 0d |  |  |  |  |  |  | 18 | 181 | 9450 | RBSE | 1802 | R1802-213 |
| 16 | 15 | Pre-job brief completed | 1d | 2007-06-08 | 2007-06-08 | 15 |  |  | 600d | 0d |  |  |  |  |  |  | 18 | 181 | 9450 | RBSE | 1802 | R1802-215 |
| 17 | 16 | Station 2 operational | 1d | 2007-06-11 | 2007-06-11 | 16 |  |  | 600d |  |  |  |  |  |  |  | 18 | 181 | 9450 | RBSE | 1802 | R1802-217 |
| 18 | 17 | Sequence plan | 1d | 2007-05-18 | 2007-05-18 |  |  |  | 575d | 0d | start no earlier than 2007-05-18 |  |  |  |  |  | 18 | 181 | 9450 | RBSE | 1802 | R1802-303 |
| 19 | 18 | Metrology plan | 1d | 2007-05-18 | 2007-05-18 |  |  |  | 575d | 0d | start no earlier than 2007-05-18 |  |  |  |  |  | 18 | 181 | 9450 | RBSE | 1802 | R1802-305 |
| 20 | 19 | Procedures approved | 10d | 2007-05-21 | 2007-06-01 | 18, 19 |  |  | 575d | 0d |  |  |  |  |  |  | 18 | 181 | 9450 | RBSE | 1802 | R1802-307 |
| 21 | 20 | JHA completed | 6d | 2007-06-04 | 2007-06-11 | 20 |  |  | 575d | 0d |  |  |  |  |  |  | 18 | 181 | 9450 | RBSE | 1802 | R1802-309 |
| 22 | 21 | Training needs identified & released | 6d | 2007-06-12 | 2007-06-19 | 21 |  |  | 575d | 0d |  |  |  |  |  |  | 18 | 181 | 9450 | RBSE | 1802 | R1802-311 |
| 23 | 22 | ACC review completed | 6d | 2007-06-20 | 2007-06-27 | 22 |  |  | 575d | 0d |  |  |  |  |  |  | 18 | 181 | 9450 | RBSE | 1802 | R1802-313 |
| 24 | 23 | Pre-job brief completed | 6d | 2007-06-28 | 2007-07-05 | 23 |  |  | 575d | 0d |  |  |  |  |  |  | 18 | 181 | 9450 | RBSE | 1802 | R1802-315 |
| 25 | 24 | Station 3 operational | 1d | 2007-07-06 | 2007-07-06 | 24 |  |  | 575d | 0d |  |  |  |  |  |  | 18 | 181 | 9450 | RBSE | 1802 | R1802-317 |
| 26 | 25 | Fixtures installed | 6d | 2007-07-09 | 2007-07-16 | 25 |  |  | 575d |  |  |  |  |  |  |  | 18 | 181 | 9450 | RBSE | 1802 | R1802-319 |
| 27 | 26 | Sequence plan | 1d | 2007-05-31 | 2007-05-31 |  |  |  | 560d | 0d | start no earlier than 2007-05-31 |  |  |  |  |  | 18 | 181 | 9450 | RBSE | 1802 | R1802-503 |
| 28 | 27 | Metrology plan | 1d | 2007-05-31 | 2007-05-31 |  |  |  | 560d | 0d | start no earlier than 2007-05-31 |  |  |  |  |  | 18 | 181 | 9450 | RBSE | 1802 | R1802-505 |
| 29 | 28 | Procedures approved | 14d | 2007-06-01 | 2007-06-20 | 27, 28 |  |  | 560d | 0d |  |  |  |  |  |  | 18 | 181 | 9450 | RBSE | 1802 | R1802-507 |
| 30 | 29 | JHA completed | 6d | 2007-06-21 | 2007-06-28 | 29 |  |  | 560d | 0d |  |  |  |  |  |  | 18 | 181 | 9450 | RBSE | 1802 | R1802-509 |
| 31 | 30 | Training needs identified & released | 6d | 2007-06-29 | 2007-07-06 | 30 |  |  | 560d | 0d |  |  |  |  |  |  | 18 | 181 | 9450 | RBSE | 1802 | R1802-511 |
| 32 | 31 | ACC review completed | 7d | 2007-07-09 | 2007-07-17 | 31 |  |  | 560d | 0d |  |  |  |  |  |  | 18 | 181 | 9450 | RBSE | 1802 | R1802-513 |
| 33 | 32 | Pre-job brief completed | 7d | 2007-07-18 | 2007-07-26 | 32 |  |  | 560d | 0d |  |  |  |  |  |  | 18 | 181 | 9450 | RBSE | 1802 | R1802-515 |
| 34 | 33 | Station 5 operational | 1d | 2007-07-27 | 2007-07-27 | 33 |  |  | 560d | 0d |  |  |  |  |  |  | 18 | 181 | 9450 | RBSE | 1802 | R1802-517 |
| 35 | 34 | Fixtures installed | 6d | 2007-07-30 | 2007-08-06 | 34 |  |  | 560d |  |  |  |  |  |  |  | 18 | 181 | 9450 | RBSE | 1802 | R1802-519 |
| 36 | 35 | LOE Crane support, fixture setupfor TFTR TC | 259.92d | 2006-10-02 A | 2007-09-28 |  | 47% | 137.91d | 0d |  | must finish on 2007-09-28 | PPPL FO&M Technician [104%] | 2071h | 1015h | 154,330.92 | 75,637.8 | 18 | 185 | 9450 | RBSE | 1810 | R1810-001 |
| 37 | 36 | LOE Crane support, fixture setupfor TFTR TC | 260.92d | 2007-10-01 | 2008-09-29 |  |  |  | 260.09d |  | start no earlier than 2007-10-01 | PPPL FO&M Technician [104%] | 2071h |  | 154,330.92 |  | 18 | 185 | 9450 | RBSE | 1810 | R1810-003 |
| 38 | 37 | LOE Field Supervision for TFTR TC FY07 | 259d | 2006-10-02 A | 2007-09-28 |  | 47% | 136.99d | 0d |  | must finish on 2007-09-28 | PPPL Electrical Senior Tech [87%] | 1726h | 846h | 190,843.82 | 93,542.22 | 18 | 185 | 9450 | RBSE | 1810 | R1810-005 |
| 39 | 38 | LOE Field Supervision for TFTR TC FY08 | 262.87d | 2007-10-01 | 2008-10-01 |  |  |  | 258.13d |  | start no earlier than 2007-10-01 | PPPL Electrical Senior Tech [86%] | 1726h |  | 190,843.82 |  | 18 | 185 | 9450 | RBSE | 1810 | R1810-007 |
| 40 | 39 | LOE Metrology support FY07 | 259.94d | 2006-10-02 A | 2007-09-28 |  | 47% | 137.93d | 0d |  | must finish on 2007-09-28 | PPPL FO&M Engineer [130%]; PPPL FO&M Technician [87%] | 4315h | 2115h | 543,948.9 | 266,616.9 | 18 | 185 | 9450 | RBSE | 1810 | R1810-009 |
| 41 | 40 | LOE Metrology support FY08 | 262.87d | 2007-10-01 | 2008-10-01 |  |  |  | 258.13d |  | start no earlier than 2007-10-01 | PPPL FO&M Engineer [129%]; PPPL FO&M Technician [86%] | 4315h |  | 543,948.9 |  | 18 | 185 | 9450 | RBSE | 1810 | R1810-011 |
| 42 | 41 | Misc M&S FY07 | 249d | 2006-10-02 A | 2007-09-13 |  | 49% | 126.99d | 10d |  | must finish on 2007-09-28 | PPPL M&S [2%]; PPPL FO&M Technician | 36h | 18h | 45,864 | 22,932 | 18 | 185 | 9450 | RBSE | 1810 | R1810-013 |
| 43 | 42 | Misc M&S FY08 | 250d | 2007-10-01 | 2008-09-12 |  |  |  | 271d |  | start no earlier than 2007-10-01 | PPPL M&S [2%]; PPPL FO&M Technician | 36h |  | 45,864 |  | 18 | 185 | 9450 | RBSE | 1810 | R1810-015 |
| 44 | 43 | Install cooling/htg lines to vac vsl | 15d | 2003-04-01 | 2003-04-21 |  |  |  | 1204.88d | 0d |  | PPPL FO&M Technician [250%] | 300h |  | 22,356 |  | 18 | 185 | 9450 | RBSE | 1810 | R1810-1103 |
| 45 | 44 | Weld cooling/htg risers | 10d | 2003-04-22 | 2003-05-05 | 44 |  |  | 1206.88d | 0d |  | PPPL M&S [3%]; PPPL FO&M Technician [250%] | 202h |  | 17,452 |  | 18 | 185 | 9450 | RBSE | 1810 | R1810-1105 |
| 46 | 45 | Verify Instl of H/C lines,headers,manifolds | 5d | 2003-05-06 | 2003-05-12 | 45 |  |  | 1256d | 0d |  | PPPL FO&M Technician [250%] | 100h |  | 7,452 |  | 18 | 185 | 9450 | RBSE | 1810 | R1810-1107 |
| 47 | 46 | Loop termination & verification | 18d | 2003-05-13 | 2003-06-05 | 46 |  |  | 1256d | 42.12d |  | PPPL FO&M Technician [250%] | 360h |  | 26,827.2 |  | 18 | 185 | 9450 | RBSE | 1810 | R1810-1109 |
| 48 | 47 | Final Scan | 4d | 2003-08-05 | 2003-08-11 | 47, 65 |  |  | 1213.88d | 0d |  | PPPL FO&M Technician [250%] | 80h |  | 5,961.6 |  | 18 | 185 | 9450 | RBSE | 1810 | R1810-1111 |
| 49 | 48 | Prepare &transfer completed VV to holding area | 2d | 2003-08-11 | 2003-08-13 | 48 |  |  | 1213.88d | 0d |  | PPPL FO&M Technician [250%] | 40h |  | 2,980.8 |  | 18 | 185 | 9450 | RBSE | 1810 | R1810-1113 |
| 50 | 49 | Misc Hardware | 127d | 2007-04-04 | 2007-09-28 |  |  |  | 0d |  | must finish on 2007-09-28 | PPPL M&S; PPPL FO&M Technician | 2h |  | 2,616 |  | 18 | 185 | 9450 | RBSE | 1810 | R1810-1203 |
| 51 | 50 | Install local I&C (incl thermocouples) | 5d | 2003-05-06 | 2003-05-12 | 45 |  |  | 1206.88d | 0d |  | PPPL FO&M Technician [250%] | 100h |  | 7,452 |  | 18 | 185 | 9450 | RBSE | 1810 | R1810-1205 |
| 52 | 51 | Verify installation of local I&C | 2d | 2003-05-13 | 2003-05-14 | 51 |  |  | 1213.88d | 0d |  | PPPL FO&M Technician [250%] | 40h |  | 2,980.8 |  | 18 | 185 | 9450 | RBSE | 1810 | R1810-1207 |
| 53 | 52 | Install cooling/htg lines to vac vsl | 15d | 2003-05-30 | 2003-06-20 | 62 |  |  | 1213.88d | 0d |  | PPPL FO&M Technician [250%] | 300h |  | 22,356 |  | 18 | 185 | 9450 | RBSE | 1810 | R1810-1209 |
| 54 | 53 | Weld cooling/htg risers | 11d | 2003-06-20 | 2003-07-07 | 53 |  |  | 1213.88d | 0d |  | PPPL M&S [3%]; PPPL FO&M Technician [250%] | 202h |  | 17,452 |  | 18 | 185 | 9450 | RBSE | 1810 | R1810-1211 |
| 55 | 54 | Verify Instl of H/C lines,headers,manifolds | 5d | 2003-08-13 | 2003-08-20 | 49 |  |  | 1275.88d | 0d |  | PPPL FO&M Technician [250%] | 100h |  | 7,452 |  | 18 | 185 | 9450 | RBSE | 1810 | R1810-1213 |
| 56 | 55 | Loop termination & verification | 19d | 2003-08-20 | 2003-09-16 | 55 |  |  | 1276.88d | 0d |  | PPPL FO&M Technician [250%] | 360h |  | 26,827.2 |  | 18 | 185 | 9450 | RBSE | 1810 | R1810-1215 |
| 57 | 56 | Final Scan | 4d | 2003-09-16 | 2003-09-22 | 56 |  |  | 1276.88d | 0d |  | PPPL FO&M Technician [250%] | 80h |  | 5,961.6 |  | 18 | 185 | 9450 | RBSE | 1810 | R1810-1217 |
| 58 | 57 | Prepare& transfer completed VV to holding area | 2d | 2003-09-22 | 2003-09-24 | 57 |  |  | 1276.88d | 0d |  | PPPL FO&M Technician [250%] | 40h |  | 2,980.8 |  | 18 | 185 | 9450 | RBSE | 1810 | R1810-1219 |
| 59 | 58 | Misc Hardware | 154d | 2007-05-15 | 2007-12-14 |  |  |  | 466d |  | start no earlier than 2007-05-15 | PPPL M&S; PPPL FO&M Technician | 2h |  | 2,689.06 |  | 18 | 185 | 9450 | RBSE | 1810 | R1810-1303 |
| 60 | 59 | Install heater tape on vertical ports | 7d | 2003-05-15 | 2003-05-23 | 52 |  |  | 1213.88d | 0d |  | PPPL FO&M Technician [250%] | 140h |  | 10,432.8 |  | 18 | 185 | 9450 | RBSE | 1810 | R1810-1305 |
| 61 | 60 | Verify installation of heater tapes | 1d | 2003-05-26 | 2003-05-26 | 60 |  |  | 1213.88d | 0d |  | PPPL FO&M Technician [250%] | 20h |  | 1,490.4 |  | 18 | 185 | 9450 | RBSE | 1810 | R1810-1307 |
| 62 | 61 | Attach studs forcoolant lines | 3.12d | 2003-05-27 | 2003-05-30 | 61 |  |  | 1213.88d | 0d |  | PPPL M&S [8%]; PPPL FO&M Technician [250%] | 62h |  | 7,019.2 |  | 18 | 185 | 9450 | RBSE | 1810 | R1810-1309 |
| 63 | 62 | Wind magnetic diagnostic sensors | 14d | 2003-07-07 | 2003-07-25 | 54 |  |  | 1213.88d | 0d |  | PPPL FO&M Technician [250%] | 280h |  | 20,865.6 |  | 18 | 185 | 9450 | RBSE | 1810 | R1810-1311 |
| 64 | 63 | Install precision magnetic diagnostic sensors | 3d | 2003-07-25 | 2003-07-30 | 63 |  |  | 1213.88d | 0d |  | PPPL FO&M Technician [250%] | 60h |  | 4,471.2 |  | 18 | 185 | 9450 | RBSE | 1810 | R1810-1313 |
| 65 | 64 | Verify installation magnetic diagnostic sensors | 4d | 2003-07-30 | 2003-08-05 | 64 |  |  | 1213.88d | 0d |  | PPPL FO&M Technician [250%] | 80h |  | 5,961.6 |  | 18 | 185 | 9450 | RBSE | 1810 | R1810-1315 |
| 66 | 65 | Install local I&C (incl thermocouples) | 5d | 2003-09-24 | 2003-10-01 | 58 |  |  | 1301.88d | 0d |  | PPPL FO&M Technician [250%] | 100h |  | 7,452 |  | 18 | 185 | 9450 | RBSE | 1810 | R1810-1317 |
| 67 | 66 | Verify installation of local I&C | 2d | 2003-10-01 | 2003-10-03 | 66 |  |  | 1301.88d | 0d |  | PPPL FO&M Technician [250%] | 40h |  | 2,980.8 |  | 18 | 185 | 9450 | RBSE | 1810 | R1810-1319 |
| 68 | 67 | Install cooling/htg lines to vac vsl | 15d | 2003-10-03 | 2003-10-24 | 67 |  |  | 1301.88d | 0d |  | PPPL FO&M Technician [250%] | 300h |  | 22,356 |  | 18 | 185 | 9450 | RBSE | 1810 | R1810-1321 |
| 69 | 68 | Weld cooling/htg risers | 10d | 2003-10-24 | 2003-11-07 | 68 |  |  | 1301.88d | 0d |  | PPPL M&S [3%]; PPPL FO&M Technician [250%] | 202h |  | 17,452 |  | 18 | 185 | 9450 | RBSE | 1810 | R1810-1323 |
| 70 | 69 | Verify Instl of H/C lines,headers,manifolds | 5d | 2003-11-07 | 2003-11-14 | 69 |  |  | 1301.88d | 0d |  | PPPL FO&M Technician [250%] | 100h |  | 7,452 |  | 18 | 185 | 9450 | RBSE | 1810 | R1810-1325 |
| 71 | 70 | Loop termination & verification | 18d | 2003-11-14 | 2003-12-10 | 70 |  |  | 1301.88d | 0d |  | PPPL FO&M Technician [250%] | 360h |  | 26,827.2 |  | 18 | 185 | 9450 | RBSE | 1810 | R1810-1327 |

| ID | WBS | Task | Type | Duration | Start | Finish | Predecessors | Remaining | Total slack | Free slack | Constraint | Resources | Work | Cost | Text2 | Text3 | Text5 | Text6 | Text7 | Text10 |
| --- | --- | --- | --- | --- | --- | --- | --- | --- | --- | --- | --- | --- | --- | --- | --- | --- | --- | --- | --- | --- |
| 72 | 71 | Final Scan |  | 4d | 2003-12-10 | 2003-12-16 | 71 |  | 1303.88d | 0d |  | PPPL FO&M Technician [250%] | 80h | 5,961.6 | 18 | 185 | 9450 | RBSE | 1810 | R1810-1329 |
| 73 | 72 | Prepare & transfer completed VV to holding area |  | 2d | 2003-12-16 | 2003-12-18 | 72 |  | 1303.88d |  |  | PPPL FO&M Technician [250%] | 40h | 2,980.8 | 18 | 185 | 9450 | RBSE | 1810 | R1810-1331 |
| 74 | 73 | Attachdiagnostics, studs and coolant lines |  | 17d | 2008-01-10 | 2008-02-01 |  |  | 431d |  | start no earlier than 2008-01-10 | PPPL FO&M Technician [250%] | 340h | 25,336.8 | 18 | 185 | 9450 | RBSE | 1810 | R1810-1S03 |
| 75 | 74 | Trial tensioning test on prototype |  | 2d | 2007-04-09 | 2007-04-10 |  |  | 644d |  | start no earlier than 2007-04-09 | PPPL M&S [19%]; PPPL FO&M Technician [250%] | 43h | 6,802.8 | 18 | 185 | 9450 | RBSE | 1810 | R1810-2003 |
| 76 | 75 | Trial bushing and shim test on prototype |  | 12.5d | 2007-04-09 | 2007-04-25 |  |  | 633.5d |  | start no earlier than 2007-04-09 | PPPL M&S [2%]; PPPL FO&M Technician [250%] | 242h | 20,432.8 | 18 | 185 | 9450 | RBSE | 1810 | R1810-2005 |
| 77 | 76 | Perform trial x-y-z alignments on A1-A2. |  | 7d | 2007-04-03 | 2007-04-11 |  |  | 636.98d | 0d | start no earlier than 2007-04-03 | PPPL M&S [4%]; PPPL FO&M Technician [250%] | 142h | 12,980.8 | 18 | 185 | 9450 | RBSE | 1810 | R1810-2009 |
| 78 | 77 | Alignment mechanisms, metro equipt &positioning |  | 6.02d | 2007-04-12 | 2007-04-20 | 77 |  | 636.98d |  |  | PPPL M&S [83%]; PPPL FO&M Technician [250%] | 160h | 59,902.4 | 18 | 185 | 9450 | RBSE | 1810 | R1810-2011 |
| 79 | 78 | Procure alignment mechanisms, fiducials, lifting |  | 20d | 2007-04-02 | 2007-04-27 |  |  | 631d |  | start no earlier than 2007-04-02 | PPPL M&S [16%]; PPPL FO&M Technician [250%] | 425h | 61,658 | 18 | 185 | 9450 | RBSE | 1810 | R1810-2013 |
| 80 | 79 | Develop procedures for torquing bolts |  | 4d | 2007-04-02 | 2007-04-05 |  |  | 634.5d | 0d | start no earlier than 2007-04-02 | PPPL FO&M Technician [250%] | 80h | 5,961.6 | 18 | 185 | 9450 | RBSE | 1810 | R1810-2015 |
| 81 | 80 | Determine fiducial types&locations |  | 12.5d | 2007-04-06 | 2007-04-24 | 80 |  | 634.5d |  |  | PPPL M&S [2%]; PPPL FO&M Technician [250%] | 222h | 18,942.4 | 18 | 185 | 9450 | RBSE | 1810 | R1810-2017 |
| 82 | 81 | Procure monuments&related metrology equipment |  | 15d | 2007-04-02 | 2007-04-20 |  |  | 636d |  | start no earlier than 2007-04-02 | PPPL M&S [13%]; PPPL FO&M Technician [250%] | 315h | 41,466 | 18 | 185 | 9450 | RBSE | 1810 | R1810-2019 |
| 83 | 82 | Tools&tooling available for FPA operations | milestone | 0d | 2007-06-12 | 2007-06-12 |  |  | 593d | 0d | finish no earlier than 2007-06-12 | PPPL FO&M Technician |  |  | 18 | 185 | 9450 | RBSE | 1810 | R1810-2021 |
| 84 | 83 | Install FIRST Holding 20 deg fixture |  | 4.17d | 2007-01-22 A | 2007-01-26 |  | 4.17d | 696.84d |  |  | PPPL M&S [6%]; PPPL FO&M Technician [250%] | 82h | 8,509.6 | 18 | 185 | 9450 | RBSE | 1810 | R1810-2023 |
| 85 | 84 | Install SECOND Holding 20 deg fixture |  | 3.12d | 2007-04-06 | 2007-04-11 |  |  | 643.88d |  | start no earlier than 2007-04-06 | PPPL M&S [8%]; PPPL FO&M Technician [250%] | 62h | 7,019.2 | 18 | 185 | 9450 | RBSE | 1810 | R1810-2025 |
| 86 | 85 | Install THIRD Holding 20 deg fixture |  | 6.25d | 2007-04-18 | 2007-04-26 |  |  | 632.75d |  | start no earlier than 2007-04-18 | PPPL M&S [4%]; PPPL FO&M Technician [250%] | 122h | 11,490.4 | 18 | 185 | 9450 | RBSE | 1810 | R1810-2027 |
| 87 | 86 | Install LAST Holding 20 deg fixture |  | 3.12d | 2007-06-06 | 2007-06-11 |  |  | 600.88d |  | start no earlier than 2007-06-06 | PPPL M&S [8%]; PPPL FO&M Technician [250%] | 62h | 7,019.2 | 18 | 185 | 9450 | RBSE | 1810 | R1810-2029 |
| 88 | 87 | Misc Hardware |  | 64.5d | 2007-06-29 | 2007-09-27 | 91 |  | 522.5d |  |  | PPPL M&S [1%]; PPPL FO&M Technician | 5h | 6,370 | 18 | 185 | 9450 | RBSE | 1810 | R1810-2103 |
| 89 | 88 | Test out equipt & procedures |  | 7d | 2007-06-12 | 2007-06-20 | 83 |  | 593d |  | start no earlier than 2007-04-11 | PPPL FO&M Technician [250%] | 140h | 10,432.8 | 18 | 185 | 9450 | RBSE | 1810 | R1810-2105 |
| 90 | 89 | Receive drawings and hardware (shims and bolts) |  | 7d | 2007-06-20 | 2007-06-28 |  |  | 0d |  | as late as possible | PPPL FO&M Technician [250%] | 140h | 10,432.8 | 18 | 185 | 9450 | RBSE | 1810 | R1810-2107 |
| 91 | 90 | HARDWARE,DRAWINGS,& PROCURES AVAILABLE STATION 2 | milestone | 0d | 2007-06-29 | 2007-06-29 | 90 |  | 0d |  | finish no earlier than 2007-06-29 |  |  |  | 18 | 185 | 9450 | RBSE | 1810 | R1810-2108 |
| 92 | 91 | Begin A1/B1/C1 |  | 1d | 2007-06-29 | 2007-06-29 | 90, 91 |  | 0d |  |  | PPPL FO&M Technician [250%] | 20h | 1,490.4 | 18 | 185 | 9450 | RBSE | 1810 | R1810-2109 |
| 93 | 92 | Pre-fit & install alignment tooling A1-A2 |  | 5d | 2007-07-02 | 2007-07-06 | 92 |  | 0d |  |  | PPPL FO&M Technician [250%] | 80h | 5,961.6 | 18 | 185 | 9450 | RBSE | 1810 | R1810-2111 |
| 94 | 93 | Align A1-A2 |  | 2d | 2007-07-09 | 2007-07-10 | 93 |  | 0d |  |  | PPPL FO&M Technician [250%] | 40h | 2,980.8 | 18 | 185 | 9450 | RBSE | 1810 | R1810-2113 |
| 95 | 94 | Install Nose shear |  | 10d | 2007-07-11 | 2007-07-24 | 94 |  | 2d |  |  | PPPL M&S [19%]; PPPL FO&M Technician [500%] | 415h | 48,918 | 18 | 185 | 9450 | RBSE | 1810 | R1810-2115 |
| 96 | 95 | Install studs |  | 2d | 2007-07-11 | 2007-07-12 | 94 |  | 0d |  |  | PPPL FO&M Technician [500%] | 80h | 5,961.6 | 18 | 185 | 9450 | RBSE | 1810 | R1810-2117 |
| 97 | 96 | Install shims |  | 5d | 2007-07-13 | 2007-07-19 | 96 |  | 0d |  |  | PPPL FO&M Technician [500%] | 200h | 14,904 | 18 | 185 | 9450 | RBSE | 1810 | R1810-2119 |
| 98 | 97 | Install Bushings |  | 5d | 2007-07-20 | 2007-07-26 | 97 |  | 0d |  |  | PPPL FO&M Technician [500%] | 200h | 14,904 | 18 | 185 | 9450 | RBSE | 1810 | R1810-2121 |
| 99 | 98 | Tension |  | 3d | 2007-07-27 | 2007-08-01 | 95, 98 |  | 0d |  |  | PPPL M&S [104%]; PPPL FO&M Technician [500%] | 145h | 40,792.4 | 18 | 185 | 9450 | RBSE | 1810 | R1810-2123 |
| 100 | 99 | Verify alignment A1-A2 |  | 2d | 2007-08-01 | 2007-08-03 | 99 |  | 0d |  |  | PPPL FO&M Technician [250%] | 40h | 2,980.8 | 18 | 185 | 9450 | RBSE | 1810 | R1810-2125 |
| 101 | 100 | De Tension |  | 1d | 2007-08-03 | 2007-08-06 | 100 |  | 0d |  |  | PPPL FO&M Technician [250%] | 20h | 1,490.4 | 18 | 185 | 9450 | RBSE | 1810 | R1810-2127 |
| 102 | 101 | Adjust Nose shear |  | 4d | 2007-08-06 | 2007-08-10 | 101 |  | 0d |  |  | PPPL FO&M Technician [250%] | 80h | 5,961.6 | 18 | 185 | 9450 | RBSE | 1810 | R1810-2129 |
| 103 | 102 | Adjust shims |  | 3d | 2007-08-10 | 2007-08-15 | 102 |  | 0d |  |  | PPPL FO&M Technician [250%] | 60h | 4,471.2 | 18 | 185 | 9450 | RBSE | 1810 | R1810-2131 |
| 104 | 103 | Adjust Bushings |  | 3d | 2007-08-15 | 2007-08-20 | 103 |  | 0d |  |  | PPPL FO&M Technician [250%] | 60h | 4,471.2 | 18 | 185 | 9450 | RBSE | 1810 | R1810-2133 |
| 105 | 104 | Re Tension |  | 3d | 2007-08-20 | 2007-08-23 | 104 |  | 0d |  |  | PPPL FO&M Technician [250%] | 60h | 4,471.2 | 18 | 185 | 9450 | RBSE | 1810 | R1810-2135 |
| 106 | 105 | Verify alignment A1-A2 |  | 2d | 2007-08-23 | 2007-08-27 | 105 |  | 0d |  |  | PPPL FO&M Technician [250%] | 40h | 2,980.8 | 18 | 185 | 9450 | RBSE | 1810 | R1810-2137 |
| 107 | 106 | De -Tension |  | 1d | 2007-08-27 | 2007-08-28 | 106 |  | 0d |  |  | PPPL FO&M Technician [250%] | 20h | 1,490.4 | 18 | 185 | 9450 | RBSE | 1810 | R1810-2139 |
| 108 | 107 | Pre-fit C1-C5 |  | 41d | 2007-08-28 | 2007-10-24 | 107 |  | 0d |  |  | PPPL FO&M Technician [400%] | 1280h | 95,385.6 | 18 | 185 | 9450 | RBSE | 1810 | R1810-2141 |
| 109 | 108 | Begin 3 pack A1/B1/C1 Install A1 |  | 3d | 2007-08-28 | 2007-08-31 | 107 |  | 8d | 0d |  | PPPL FO&M Technician [250%] | 60h | 4,471.2 | 18 | 185 | 9450 | RBSE | 1810 | R1810-2143 |
| 110 | 109 | Fit A1-B1 |  | 41d | 2007-08-31 | 2007-10-29 | 109 |  | 8d | 0d |  | PPPL FO&M Technician [500%] | 1600h | 119,232 | 18 | 185 | 9450 | RBSE | 1810 | R1810-2145 |
| 111 | 110 | Fit B1-C1 |  | 49d | 2007-10-29 | 2008-01-04 | 108, 110 |  | 8d | 0d |  | PPPL FO&M Technician [500%] | 1600h | 119,232 | 18 | 185 | 9450 | RBSE | 1810 | R1810-2147 |
| 112 | 111 | Verify Align Mod-Coils A1/B1/C1 |  | 5d | 2008-01-04 | 2008-01-11 | 111 |  | 8d | 0d |  | PPPL FO&M Technician [250%] | 100h | 7,452 | 18 | 185 | 9450 | RBSE | 1810 | R1810-2149 |
| 113 | 112 | Pre-fit C2-C3 |  | 42d | 2007-10-24 | 2007-12-21 | 108 |  | 0d |  |  | PPPL FO&M Technician [400%] | 1280h | 95,385.6 | 18 | 185 | 9450 | RBSE | 1810 | R1810-2151 |
| 114 | 113 | Fit A2-B2 |  | 47d | 2007-12-21 | 2008-02-26 | 113 |  | 0d |  |  | PPPL FO&M Technician [500%] | 1600h | 119,232 | 18 | 185 | 9450 | RBSE | 1810 | R1810-2153 |
| 115 | 114 | Fit B2-C2 |  | 40d | 2008-02-26 | 2008-04-22 | 114 |  | 0d |  |  | PPPL FO&M Technician [500%] | 1600h | 119,232 | 18 | 185 | 9450 | RBSE | 1810 | R1810-2155 |
| 116 | 115 | Verify Align Mod-Coils A2/B2/C2 |  | 5d | 2008-04-22 | 2008-04-29 | 115 |  | 0d |  |  | PPPL FO&M Technician [250%] | 100h | 7,452 | 18 | 185 | 9450 | RBSE | 1810 | R1810-2157 |
| 117 | 116 | Assemble/Align Mod-Coils A3/B3/C3 |  | 80d | 2008-01-11 | 2008-05-02 | 112 |  | 8d | 0d |  | PPPL FO&M Technician [500%] | 3200h | 238,464 | 18 | 185 | 9450 | RBSE | 1810 | R1810-2203 |
| 118 | 117 | Pre-fit C6-C4 |  | 40d | 2008-03-19 | 2008-05-14 |  |  | 0d |  | as late as possible | PPPL FO&M Technician [400%] | 1280h | 95,385.6 | 18 | 185 | 9450 | RBSE | 1810 | R1810-2205 |
| 119 | 118 | Assemble/Align Mod-Coils A4/B4/C4 |  | 83d | 2008-05-14 | 2008-09-08 | 117, 118 |  | 0d |  |  | PPPL FO&M Technician [500%] | 3200h | 238,464 | 18 | 185 | 9450 | RBSE | 1810 | R1810-2207 |
| 120 | 119 | Assemble/Align Mod-Coils A5/B5/C5 |  | 82d | 2008-05-02 | 2008-08-26 | 117 |  | 85d |  |  | PPPL FO&M Technician [500%] | 3200h | 238,464 | 18 | 185 | 9450 | RBSE | 1810 | R1810-2303 |
| 121 | 120 | Assemble/Align Mod-Coils A6/B6/C6 |  | 89d | 2008-09-08 | 2009-01-09 | 119 |  | 5d |  |  | PPPL FO&M Technician [500%] | 3200h | 238,464 | 18 | 185 | 9450 | RBSE | 1810 | R1810-2305 |
| 122 | 121 | Misc Hardware |  | 9d | 2008-04-02 | 2008-04-15 |  |  | 0d |  | as late as possible | PPPL M&S [7%]; PPPL FO&M Technician | 5h | 6,370 | 18 | 185 | 9450 | RBSE | 1810 | R1810-3103 |
| 123 | 122 | Begin Assembly of First Field Period Assy |  | 2d | 2008-04-02 | 2008-04-04 |  |  | 0d |  | as late as possible | PPPL FO&M Technician [250%] | 40h | 2,980.8 | 18 | 185 | 9450 | RBSE | 1810 | R1810-3105 |
| 124 | 123 | Test out station 3 equipment and procedures |  | 2d | 2008-04-04 | 2008-04-08 | 123 |  | 0d |  | as late as possible | PPPL M&S [63%]; PPPL FO&M Technician [250%] | 50h | 15,720.8 | 18 | 185 | 9450 | RBSE | 1810 | R1810-3107 |
| 125 | 124 | VV to MC turning fixt base; metr check |  | 3d | 2008-04-08 | 2008-04-11 | 49, 124 |  | 0d |  | as late as possible | PPPL FO&M Technician [250%] | 60h | 4,471.2 | 18 | 185 | 9450 | RBSE | 1810 | R1810-3111 |
| 126 | 125 | Attach local protective strips to VV&locate sens |  | 2d | 2008-04-11 | 2008-04-15 | 125 |  | 0d |  | as late as possible | PPPL FO&M Technician [250%] | 40h | 2,980.8 | 18 | 185 | 9450 | RBSE | 1810 | R1810-3113 |
| 127 | 126 | Mount MC on crane; perform metr checks |  | 4d | 2008-04-15 | 2008-04-21 | 112, 122, 126 |  | 0d |  |  | PPPL M&S [25%]; PPPL FO&M Technician [250%] | 88h | 16,153.6 | 18 | 185 | 9450 | RBSE | 1810 | R1810-3115 |
| 128 | 127 | Rotate right MC to stand-off position&chk |  | 3d | 2008-04-21 | 2008-04-24 | 127 |  | 0d |  |  | PPPL FO&M Technician [250%] | 60h | 4,471.2 | 18 | 185 | 9450 | RBSE | 1810 | R1810-3117 |
| 129 | 128 | Transfer load to sprt sys and recheck position |  | 3d | 2008-04-24 | 2008-04-29 | 128 |  | 0d |  |  | PPPL FO&M Technician [250%] | 60h | 4,471.2 | 18 | 185 | 9450 | RBSE | 1810 | R1810-3119 |
| 130 | 129 | Move MC turning fixt; mount MC on crane |  | 5d | 2008-04-29 | 2008-05-06 | 116, 129 |  | 0d |  |  | PPPL FO&M Technician [250%] | 100h | 7,452 | 18 | 185 | 9450 | RBSE | 1810 | R1810-3121 |
| 131 | 130 | Rotate left MC to stand-off position and check p |  | 5d | 2008-05-06 | 2008-05-13 | 130 |  | 0d |  |  | PPPL FO&M Technician [250%] | 100h | 7,452 | 18 | 185 | 9450 | RBSE | 1810 | R1810-3123 |
| 132 | 131 | Move left & right MC to final position & measure |  | 6d | 2008-05-13 | 2008-05-21 | 131 |  | 0d |  |  | PPPL FO&M Technician [250%] | 120h | 8,942.4 | 18 | 185 | 9450 | RBSE | 1810 | R1810-3125 |
| 133 | 132 | Pot 3 packs together |  | 11d | 2008-05-21 | 2008-06-05 | 132 |  | 0d |  |  | PPPL FO&M Technician [250%] | 200h | 14,904 | 18 | 185 | 9450 | RBSE | 1810 | R1810-3127 |
| 134 | 133 | Bolt together at flange interface. |  | 36d | 2008-06-05 | 2008-07-25 | 133 |  | 0d |  |  | PPPL FO&M Technician [250%] | 700h | 52,164 | 18 | 185 | 9450 | RBSE | 1810 | R1810-3129 |
| 135 | 134 | Perform final metrology position check |  | 2d | 2008-07-25 | 2008-07-29 | 134 |  | 0d |  |  | PPPL FO&M Technician [250%] | 40h | 2,980.8 | 18 | 185 | 9450 | RBSE | 1810 | R1810-3131 |
| 136 | 135 | Remove temp interference strips&sensors |  | 1d | 2008-07-29 | 2008-07-30 | 135 |  | 0d |  |  | PPPL FO&M Technician [250%] | 20h | 1,490.4 | 18 | 185 | 9450 | RBSE | 1810 | R1810-3133 |
| 137 | 136 | Secure VV to MC's using temporary supports. |  | 5d | 2008-07-30 | 2008-08-06 | 136 |  | 0d |  |  | PPPL FO&M Technician [250%] | 100h | 7,452 | 18 | 185 | 9450 | RBSE | 1810 | R1810-3135 |
| 138 | 137 | Prepare Field Period for shipment |  | 5d | 2008-08-06 | 2008-08-13 | 137 |  | 0d |  |  | PPPL FO&M Technician [250%] | 100h | 7,452 | 18 | 185 | 9450 | RBSE | 1810 | R1810-3137 |
| 139 | 138 | Transfer completed assy to C-site test cell |  | 2d | 2008-08-13 | 2008-08-15 | 138 |  | 0d |  |  | PPPL FO&M Technician [250%] | 40h | 2,980.8 | 18 | 185 | 9450 | RBSE | 1810 | R1810-3139 |
| 140 | 139 | Mount VV to MC turning fixt base; metr check |  | 3d | 2008-08-15 | 2008-08-20 | 58, 139 |  | 0d |  |  | PPPL FO&M Technician [250%] | 60h | 4,471.2 | 18 | 185 | 9450 | RBSE | 1810 | R1810-3203 |
| 141 | 140 | Attach local protective strips to VV&locate sens |  | 2d | 2008-08-20 | 2008-08-22 | 140 |  | 0d |  |  | PPPL FO&M Technician [250%] | 40h | 2,980.8 | 18 | 185 | 9450 | RBSE | 1810 | R1810-3205 |

| ID | WBS | Task | Duration | Start | Finish | Predecessors | Total slack | Free slack | Constraint | Resources | Work | Cost | Text2 | Text3 | Text5 | Text6 | Text7 | Text10 |
| --- | --- | --- | --- | --- | --- | --- | --- | --- | --- | --- | --- | --- | --- | --- | --- | --- | --- | --- |
| 142 | 141 | Mount MC on crane; perform metr checks | 4d | 2008-08-22 | 2008-08-28 | 117, 141 | 0d |  |  | PPPL FO&M Technician [250%] | 80h | 5,961.6 | 18 | 185 | 9450 | RBSE | 1810 | R1810-3207 |
| 143 | 142 | Rotate right MC to stand-off position&chk | 4d | 2008-08-28 | 2008-09-03 | 142 | 0d |  |  | PPPL FO&M Technician [250%] | 60h | 4,471.2 | 18 | 185 | 9450 | RBSE | 1810 | R1810-3209 |
| 144 | 143 | Transfer load to supt sys and recheck position | 3d | 2008-09-03 | 2008-09-08 | 143 | 0d |  |  | PPPL FO&M Technician [250%] | 60h | 4,471.2 | 18 | 185 | 9450 | RBSE | 1810 | R1810-3211 |
| 145 | 144 | Move MC turning fixt; mount MC on crane | 5d | 2008-09-08 | 2008-09-15 | 119, 144 | 0d |  |  | PPPL FO&M Technician [250%] | 100h | 7,452 | 18 | 185 | 9450 | RBSE | 1810 | R1810-3213 |
| 146 | 145 | Rotate left MC to stand-off position and check p | 5d | 2008-09-15 | 2008-09-22 | 145 | 0d |  |  | PPPL FO&M Technician [250%] | 100h | 7,452 | 18 | 185 | 9450 | RBSE | 1810 | R1810-3215 |
| 147 | 146 | Move left & right MC to final position & measure | 6d | 2008-09-22 | 2008-09-30 | 146 | 0d |  |  | PPPL FO&M Technician [250%] | 120h | 8,942.4 | 18 | 185 | 9450 | RBSE | 1810 | R1810-3217 |
| 148 | 147 | Pot 3 packs together | 8d | 2008-09-30 | 2008-10-10 | 147 | 0d |  |  | PPPL FO&M Technician [250%] | 160h | 11,923.2 | 18 | 185 | 9450 | RBSE | 1810 | R1810-3219 |
| 149 | 148 | Bolt together at flange interface. | 30d | 2008-10-10 | 2008-11-21 | 148 | 0d |  |  | PPPL FO&M Technician [250%] | 600h | 44,712 | 18 | 185 | 9450 | RBSE | 1810 | R1810-3221 |
| 150 | 149 | Perform final metrology position check | 3d | 2008-11-21 | 2008-11-26 | 149 | 0d |  |  | PPPL FO&M Technician [250%] | 60h | 4,471.2 | 18 | 185 | 9450 | RBSE | 1810 | R1810-3223 |
| 151 | 150 | Remove temp interference strips&sensors | 3d | 2008-11-26 | 2008-12-01 | 150 | 0d |  |  | PPPL FO&M Technician [250%] | 20h | 1,490.4 | 18 | 185 | 9450 | RBSE | 1810 | R1810-3225 |
| 152 | 151 | Secure VV to MC's using temporary supports. | 5d | 2008-12-01 | 2008-12-08 | 151 | 0d |  |  | PPPL FO&M Technician [250%] | 100h | 7,452 | 18 | 185 | 9450 | RBSE | 1810 | R1810-3227 |
| 153 | 152 | Prepare Field Period for shipment | 5d | 2008-12-08 | 2008-12-15 | 152 | 0d |  |  | PPPL FO&M Technician [250%] | 100h | 7,452 | 18 | 185 | 9450 | RBSE | 1810 | R1810-3229 |
| 154 | 153 | Transfer completed assy to C-site test cell | 2d | 2008-12-15 | 2008-12-17 | 153 | 0d |  |  | PPPL FO&M Technician [250%] | 40h | 2,980.8 | 18 | 185 | 9450 | RBSE | 1810 | R1810-3231 |
| 155 | 154 | Mount VV to MC turning fixt base; metr check | 3d | 2008-12-17 | 2008-12-22 | 73, 154 | 0d |  |  | PPPL FO&M Technician [250%] | 60h | 4,471.2 | 18 | 185 | 9450 | RBSE | 1810 | R1810-3303 |
| 156 | 155 | Attach local protective strips to VV&locate sens | 9d | 2008-12-22 | 2009-01-02 | 155 | 0d |  |  | PPPL FO&M Technician [250%] | 40h | 2,980.8 | 18 | 185 | 9450 | RBSE | 1810 | R1810-3305 |
| 157 | 156 | Mount MC on crane; perform metr checks | 4d | 2009-01-02 | 2009-01-08 | 120, 156 | 0d |  |  | PPPL FO&M Technician [250%] | 80h | 5,961.6 | 18 | 185 | 9450 | RBSE | 1810 | R1810-3307 |
| 158 | 157 | Rotate right MC to stand-off position&chk | 3d | 2009-01-08 | 2009-01-13 | 157 | 0d |  |  | PPPL FO&M Technician [250%] | 60h | 4,471.2 | 18 | 185 | 9450 | RBSE | 1810 | R1810-3309 |
| 159 | 158 | Transfer load to supt sysand recheck position | 3d | 2009-01-13 | 2009-01-16 | 158 | 0d |  |  | PPPL FO&M Technician [250%] | 60h | 4,471.2 | 18 | 185 | 9450 | RBSE | 1810 | R1810-3311 |
| 160 | 159 | Move MC turning fixt; mount MC on crane | 5d | 2009-01-16 | 2009-01-23 | 121, 159 | 0d |  |  | PPPL FO&M Technician [250%] | 100h | 7,452 | 18 | 185 | 9450 | RBSE | 1810 | R1810-3313 |
| 161 | 160 | Rotate left MC to stand-off position and check p | 5d | 2009-01-23 | 2009-01-30 | 160 | 0d |  |  | PPPL FO&M Technician [250%] | 100h | 7,452 | 18 | 185 | 9450 | RBSE | 1810 | R1810-3315 |
| 162 | 161 | Move left & right MC to final position & measure | 6d | 2009-01-30 | 2009-02-09 | 161 | 0d |  |  | PPPL FO&M Technician [250%] | 120h | 8,942.4 | 18 | 185 | 9450 | RBSE | 1810 | R1810-3317 |
| 163 | 162 | Pot 3 packs together | 8d | 2009-02-09 | 2009-02-19 | 162 | 0d |  |  | PPPL FO&M Technician [250%] | 160h | 11,923.2 | 18 | 185 | 9450 | RBSE | 1810 | R1810-3319 |
| 164 | 163 | Bolt together at flange interface. | 25d | 2009-02-19 | 2009-03-26 | 163 | 0d |  |  | PPPL FO&M Technician [250%] | 500h | 37,260 | 18 | 185 | 9450 | RBSE | 1810 | R1810-3321 |
| 165 | 164 | Perform final metrology position check | 3d | 2009-03-26 | 2009-03-31 | 164 | 0d |  |  | PPPL FO&M Technician [250%] | 60h | 4,471.2 | 18 | 185 | 9450 | RBSE | 1810 | R1810-3323 |
| 166 | 165 | Remove temp interference strips&sensors | 1d | 2009-03-31 | 2009-04-01 | 165 | 0d |  |  | PPPL FO&M Technician [250%] | 20h | 1,490.4 | 18 | 185 | 9450 | RBSE | 1810 | R1810-3325 |
| 167 | 166 | metrology network | 10d | 2007-10-01 | 2007-10-12 |  | 365d | 0d | start no earlier than 2007-10-01 | PPPL M&S [9%]; PPPL FO&M Technician [200%] | 167h | 20,841.2 | 18 | 185 | 9450 | RBSE | 1815 | R1810-5103 |
| 168 | 167 | Weld Wire & weld supples | 31.25d | 2009-02-24 | 2009-04-09 |  | 0d |  | as late as possible | PPPL M&S [6%]; PPPL FO&M Technician | 15h | 19,110 | 18 | 185 | 9450 | RBSE | 1815 | R1810-5105 |
| 169 | 168 | Testout Sta 5 equipt & procedures | 5d | 2007-10-15 | 2007-10-19 | 167 | 365d | 214d |  | PPPL FO&M Technician [400%] | 160h | 11,923.2 | 18 | 185 | 9450 | RBSE | 1815 | R1810-5107 |
| 170 | 169 | Install on support platform | 16d | 2008-08-15 | 2008-09-08 | 139, 169 | 151d | 0d |  | PPPL M&S [10%]; PPPL FO&M Technician [500%] | 612h | 60,000 | 18 | 185 | 9450 | RBSE | 1815 | R1810-5109 |
| 171 | 170 | Mount MC/VV assembly to support frame a | 2d | 2008-09-08 | 2008-09-10 | 170 | 151d |  |  | PPPL FO&M Technician [250%] | 40h | 2,980.8 | 18 | 185 | 9450 | RBSE | 1815 | R1810-5111 |
| 172 | 171 | Position and weld all ports to VV incl 2 extens | 29d | 2009-04-09 | 2009-05-20 | 168, 171 | 0d |  |  | PPPL FO&M Technician [250%] | 580h | 43,221.6 | 18 | 185 | 9450 | RBSE | 1815 | R1810-5113 |
| 173 | 172 | Inspect Welds | 5d | 2009-05-20 | 2009-05-27 | 172 | 0d |  |  | PPPL FO&M Technician [250%] | 80h | 5,961.6 | 18 | 185 | 9450 | RBSE | 1815 | R1810-5115 |
| 174 | 173 | Assemble left TF Coil Assembly check position | 8d | 2009-05-27 | 2009-06-08 | 173 | 0d |  |  | PPPL FO&M Technician [400%] | 256h | 19,077.12 | 18 | 185 | 9450 | RBSE | 1815 | R1810-5117 |
| 175 | 174 | Change platforms | 1d | 2009-06-08 | 2009-06-09 | 174 | 0d |  |  | PPPL FO&M Technician [250%] | 20h | 1,490.4 | 18 | 185 | 9450 | RBSE | 1815 | R1810-5119 |
| 176 | 175 | Assemble right TF Coil Assembly chk position | 8d | 2009-06-09 | 2009-06-19 | 175 | 0d |  |  | PPPL FO&M Technician [400%] | 256h | 19,077.12 | 18 | 185 | 9450 | RBSE | 1815 | R1810-5121 |
| 177 | 176 | Attach TF coils to MC's | 4d | 2009-06-19 | 2009-06-25 | 176 | 0d |  |  | PPPL FO&M Technician [250%] | 80h | 5,961.6 | 18 | 185 | 9450 | RBSE | 1815 | R1810-5123 |
| 178 | 177 | Align TF Coils | 10d | 2009-06-25 | 2009-07-09 | 177 | 0d |  |  | PPPL FO&M Technician [250%] | 160h | 11,923.2 | 18 | 185 | 9450 | RBSE | 1815 | R1810-5125 |
| 179 | 178 | Change platforms | 1d | 2009-07-09 | 2009-07-10 | 178 | 0d |  |  | PPPL FO&M Technician [250%] | 20h | 1,490.4 | 18 | 185 | 9450 | RBSE | 1815 | R1810-5127 |
| 180 | 179 | Position, tack-weld two large horiz diag port 4' | 19d | 2009-07-10 | 2009-08-06 | 179 | 0d |  |  | PPPL FO&M Technician [250%] | 240h | 17,884.8 | 18 | 185 | 9450 | RBSE | 1815 | R1810-5129 |
| 181 | 180 | Inspect Welds | 5d | 2009-08-06 | 2009-08-13 | 180 | 0d |  |  | PPPL FO&M Technician [250%] | 100h | 7,452 | 18 | 185 | 9450 | RBSE | 1815 | R1810-5131 |
| 182 | 181 | Assemble external trim coils (in wbs75) | 15d | 2009-08-13 | 2009-09-03 | 181 | 0d |  |  | PPPL FO&M Technician [250%] | 300h | 22,356 | 18 | 185 | 9450 | RBSE | 1815 | R1810-5133 |
| 183 | 182 | Adjust final support base interfaces | 8d | 2009-09-03 | 2009-09-15 | 182 | 0d |  |  | PPPL FO&M Technician [250%] | 160h | 11,923.2 | 18 | 185 | 9450 | RBSE | 1815 | R1810-5135 |
| 184 | 183 | Final metrology outside & inside | 10d | 2009-09-15 | 2009-09-29 | 183 | 0d |  |  | PPPL FO&M Technician [250%] | 200h | 14,904 | 18 | 185 | 9450 | RBSE | 1815 | R1810-5137 |
| 185 | 184 | Install on support platform | 22d | 2008-12-17 | 2009-01-16 | 154 | 68d | 0d |  | PPPL FO&M Technician [500%] | 600h | 44,712 | 18 | 185 | 9450 | RBSE | 1815 | R1810-5203 |
| 186 | 185 | Mount MC/VV assembly to support frame a | 2d | 2009-01-16 | 2009-01-20 | 185 | 68d | 0d |  | PPPL FO&M Technician [250%] | 40h | 2,980.8 | 18 | 185 | 9450 | RBSE | 1815 | R1810-5205 |
| 187 | 186 | Position and weld all ports to VV | 25d | 2009-01-20 | 2009-02-24 | 186 | 68d | 0d |  | PPPL FO&M Technician [250%] | 500h | 37,260 | 18 | 185 | 9450 | RBSE | 1815 | R1810-5207 |
| 188 | 187 | Inspect Welds | 4d | 2009-02-24 | 2009-03-02 | 187 | 69d | 0d |  | PPPL FO&M Technician [250%] | 80h | 5,961.6 | 18 | 185 | 9450 | RBSE | 1815 | R1810-5209 |
| 189 | 188 | Assemble left TF Coil Assembly check position | 8d | 2009-03-02 | 2009-03-12 | 188 | 69d | 0d |  | PPPL FO&M Technician [400%] | 256h | 19,077.12 | 18 | 185 | 9450 | RBSE | 1815 | R1810-5211 |
| 190 | 189 | Change platforms | 1d | 2009-03-12 | 2009-03-13 | 189 | 69d | 0d |  | PPPL FO&M Technician [250%] | 20h | 1,490.4 | 18 | 185 | 9450 | RBSE | 1815 | R1810-5213 |
| 191 | 190 | Assemble right TF Coil Assembly chk position | 8d | 2009-03-13 | 2009-03-25 | 190 | 69d | 0d |  | PPPL FO&M Technician [400%] | 256h | 19,077.12 | 18 | 185 | 9450 | RBSE | 1815 | R1810-5215 |
| 192 | 191 | Attach TF coils to MC's | 4d | 2009-03-25 | 2009-03-31 | 191 | 69d | 0d |  | PPPL FO&M Technician [250%] | 80h | 5,961.6 | 18 | 185 | 9450 | RBSE | 1815 | R1810-5217 |
| 193 | 192 | Align TF Coils | 8d | 2009-03-31 | 2009-04-10 | 192 | 70d | 0d |  | PPPL FO&M Technician [250%] | 160h | 11,923.2 | 18 | 185 | 9450 | RBSE | 1815 | R1810-5219 |
| 194 | 193 | Change platforms | 1d | 2009-04-10 | 2009-04-13 | 193 | 70d | 0d |  | PPPL FO&M Technician [250%] | 20h | 1,490.4 | 18 | 185 | 9450 | RBSE | 1815 | R1810-5221 |
| 195 | 194 | Position, tack-weld two large horiz diag port 4' | 12d | 2009-04-13 | 2009-04-29 | 194 | 70d | 0d |  | PPPL FO&M Technician [250%] | 240h | 17,884.8 | 18 | 185 | 9450 | RBSE | 1815 | R1810-5223 |
| 196 | 195 | Inspect Welds | 5d | 2009-04-29 | 2009-05-06 | 195 | 70d | 0d |  | PPPL FO&M Technician [250%] | 100h | 7,452 | 18 | 185 | 9450 | RBSE | 1815 | R1810-5225 |
| 197 | 196 | Assemble external trim coils (in wbs75) | 16d | 2009-05-06 | 2009-05-28 | 196 | 70d | 0d |  | PPPL FO&M Technician [250%] | 300h | 22,356 | 18 | 185 | 9450 | RBSE | 1815 | R1810-5227 |
| 198 | 197 | Adjust final support base interfaces | 8d | 2009-05-28 | 2009-06-09 | 197 | 70d | 0d |  | PPPL FO&M Technician [250%] | 160h | 11,923.2 | 18 | 185 | 9450 | RBSE | 1815 | R1810-5229 |
| 199 | 198 | Final metrology outside & inside | 10d | 2009-06-09 | 2009-06-23 | 198 | 70d |  |  | PPPL FO&M Technician [250%] | 200h | 14,904 | 18 | 185 | 9450 | RBSE | 1815 | R1810-5231 |
| 200 | 199 | Install on support platform | 15d | 2009-04-01 | 2009-04-22 | 166 | 0d |  |  | PPPL FO&M Technician [500%] | 600h | 44,712 | 18 | 185 | 9450 | RBSE | 1815 | R1810-5303 |
| 201 | 200 | Mount MC/VV assembly to support frame a | 2d | 2009-04-22 | 2009-04-24 | 200 | 0d |  |  | PPPL FO&M Technician [250%] | 40h | 2,980.8 | 18 | 185 | 9450 | RBSE | 1815 | R1810-5305 |
| 202 | 201 | Position and weld all ports to VV*2 shift* | 26d | 2009-04-24 | 2009-06-01 | 201 | 0d |  |  | PPPL FO&M Technician [250%] | 500h | 37,260 | 18 | 185 | 9450 | RBSE | 1815 | R1810-5307 |
| 203 | 202 | Inspect Welds | 4d | 2009-06-01 | 2009-06-05 | 202 | 0d |  |  | PPPL FO&M Technician [250%] | 80h | 5,961.6 | 18 | 185 | 9450 | RBSE | 1815 | R1810-5309 |
| 204 | 203 | Assemble left TF Coil Assembly check position | 8d | 2009-06-05 | 2009-06-17 | 203 | 0d |  |  | PPPL FO&M Technician [400%] | 256h | 19,077.12 | 18 | 185 | 9450 | RBSE | 1815 | R1810-5311 |
| 205 | 204 | Change platforms | 1d | 2009-06-17 | 2009-06-18 | 204 | 0d |  |  | PPPL FO&M Technician [250%] | 20h | 1,490.4 | 18 | 185 | 9450 | RBSE | 1815 | R1810-5313 |
| 206 | 205 | Assemble right TF Coil Assembly chk position | 8d | 2009-06-18 | 2009-06-30 | 205 | 0d |  |  | PPPL FO&M Technician [400%] | 256h | 19,077.12 | 18 | 185 | 9450 | RBSE | 1815 | R1810-5315 |
| 207 | 206 | Attach TF coils to MC's | 5d | 2009-06-30 | 2009-07-07 | 206 | 0d |  |  | PPPL FO&M Technician [250%] | 80h | 5,961.6 | 18 | 185 | 9450 | RBSE | 1815 | R1810-5317 |
| 208 | 207 | Align TF Coils | 8d | 2009-07-07 | 2009-07-17 | 207 | 0d |  |  | PPPL FO&M Technician [250%] | 160h | 11,923.2 | 18 | 185 | 9450 | RBSE | 1815 | R1810-5319 |
| 209 | 208 | Change platforms | 1d | 2009-07-17 | 2009-07-20 | 208 | 0d |  |  | PPPL FO&M Technician [250%] | 20h | 1,490.4 | 18 | 185 | 9450 | RBSE | 1815 | R1810-5321 |
| 210 | 209 | Position, tack-weld two large horiz diag port 4' | 12d | 2009-07-20 | 2009-08-05 | 209 | 0d |  |  | PPPL FO&M Technician [250%] | 240h | 17,884.8 | 18 | 185 | 9450 | RBSE | 1815 | R1810-5323 |
| 211 | 210 | Inspect Welds | 5d | 2009-08-05 | 2009-08-12 | 210 | 0d |  |  | PPPL FO&M Technician [250%] | 100h | 7,452 | 18 | 185 | 9450 | RBSE | 1815 | R1810-5325 |

| ID | WBS | Task | Duration | Start | Finish | Predecessors | Total slack | Resources | Work | Cost | Text2 | Text3 | Text5 | Text6 | Text7 | Text10 |
| --- | --- | --- | --- | --- | --- | --- | --- | --- | --- | --- | --- | --- | --- | --- | --- | --- |
| 212 | 211 | Assemble external trim coils (in wbs75) | 15d | 2009-08-12 | 2009-09-02 | 211 | 0d | PPPL FO&M Technician [250%] | 300h | 22,356 | 18 | 185 | 9450 | RBSE | 1815 | R1810-5327 |
| 213 | 212 | Adjust final support base interfaces | 8d | 2009-09-02 | 2009-09-14 | 212 | 0d | PPPL FO&M Technician [250%] | 160h | 11,923.2 | 18 | 185 | 9450 | RBSE | 1815 | R1810-5329 |
| 214 | 213 | Final metrology outside & inside | 10d | 2009-09-14 | 2009-09-28 | 213 | 0d | PPPL FO&M Technician [250%] | 200h | 14,904 | 18 | 185 | 9450 | RBSE | 1815 | R1810-5331 |
| 215 | 214 | Last field period assembled | 1d | 2009-09-28 | 2009-09-29 | 214 | 0d | PPPL FO&M Technician [250%] | 20h | 1,490.4 | 18 | 185 | 9450 | RBSE | 1815 | R1810-5333 |
